# Aries Part 1

Schedule from Planner, 2004-09-27 to 2004-10-18.

## Calendars

- Default: Mon-Sat 08:00-12:00, 13:00-19:00; Sun off. Exceptions (off unless hours are given): 2004-10-01 to 2004-10-02.

## Schedule

| ID | Task | Type | Duration | Start | Finish | Predecessors | Constraint | Work |
| --- | --- | --- | --- | --- | --- | --- | --- | --- |
| 1 | [ARIES] Define temp & vacuum ctrlr reqmts |  |  | 2004-09-27 | 2004-09-27 |  | must start on 2004-09-27 | 10h |
| 2 | [ARIES] Slit design |  |  | 2004-09-27 | 2004-10-05 |  | must start on 2004-09-27 | 60h |
| 3 | [SW] Build new GNUstep foundation |  |  | 2004-09-28 | 2004-09-28 |  | must start on 2004-09-28 | 10h |
| 4 | [ARIES] Make remote Lakeshore cable |  |  | 2004-09-28 | 2004-09-29 |  | must start on 2004-09-28 | 20h |
| 5 | [ARIES] Specify serial IO controller |  |  | 2004-09-29 | 2004-09-29 |  | must start on 2004-09-29 | 10h |
| 6 | [ARIES] Make remote vacuum cable |  |  | 2004-09-29 | 2004-09-30 |  | must start on 2004-09-29 | 20h |
| 7 | [SW] Finish basic instrument GUI |  |  | 2004-09-28 | 2004-10-05 |  | must start on 2004-09-28 | 50h |
| 8 | [ARIES] pump down |  |  | 2004-09-29 | 2004-09-30 |  | must start on 2004-09-29 | 20h |
| 9 | [SW] Implement array bias "setup" function |  |  | 2004-09-30 | 2004-09-30 |  | must start on 2004-09-30 | 10h |
| 10 | [ARIES] Cool down |  |  | 2004-10-01 | 2004-10-05 | 8 | must start on 2004-10-01 | 20h |
| 11 | [SW] Housekeeping display |  |  | 2004-10-04 | 2004-10-04 |  | must start on 2004-10-04 | 10h |
| 12 | [ARIES] Evaluate detector performance |  |  | 2004-10-04 | 2004-10-04 |  | must start on 2004-10-04 | 10h |
| 13 | [ARIES] Place req order for slits & controllers | milestone | 0d | 2004-10-05 | 2004-10-05 |  | must start on 2004-10-05 |  |
| 14 | [ARIES] Optimize detector performance |  |  | 2004-10-05 | 2004-10-05 |  | must start on 2004-10-05 | 10h |
| 15 | [ARIES] Eval old motor controller noise |  |  | 2004-10-06 | 2004-10-06 |  | must start on 2004-10-06 | 10h |
| 16 | [ARIES] Eval new motor controller noise |  |  | 2004-10-07 | 2004-10-07 |  | must start on 2004-10-07 | 10h |
| 17 | [ARIES] Simultaneous operation of 2 arrays | milestone | 0d | 2004-10-08 | 2004-10-08 |  | must start on 2004-10-08 |  |
| 18 | [ARIES] Calibrate XY prober |  |  | 2004-10-08 | 2004-10-08 |  | must start on 2004-10-08 | 10h |
| 19 | [ARIES] Test some x-talk elimination methods |  |  | 2004-10-09 | 2004-10-11 |  | must start on 2004-10-09 | 20h |
| 20 | [ARIES] Warm up |  |  | 2004-10-12 | 2004-10-12 |  | must start on 2004-10-12 | 10h |
| 21 | [SW] Finish new motor code |  |  | 2004-10-12 | 2004-10-13 |  | must start on 2004-10-12 | 20h |
| 22 | [SW] Port PCI driver to kernel 2.6 |  |  | 2004-10-14 | 2004-10-15 |  | must start on 2004-10-14 | 20h |
| 23 | [DOC] Aries & Pisces Web Pages |  |  | 2004-10-15 | 2004-10-18 |  | must start on 2004-10-15 | 30h |
